# Planification_du_projet

Schedule from MS Project, 2025-09-01 to 2025-12-16, costs in €.

## Calendars

- Standard: Mon-Fri 08:00-12:00, 13:00-17:00; Sat-Sun off.

## Resources

| Resource |
| --- |
| CP |
| Direction |
| Formateurs |
| RQ |
| Toute l'équipe |
| RP |
| Support tech |
| Équipe projet |
| Chargé de com |

## Schedule

| ID | WBS | Task | Duration | Start | Finish | Predecessors | Total slack | Resources | Work | Cost |
| --- | --- | --- | --- | --- | --- | --- | --- | --- | --- | --- |
| 1 | 1 | **SCRUM PRO+** | 77d | 2025-09-01 | 2025-12-16 |  | 0d |  | 624h | 9,950 |
| 2 | 1.1 | **Cadrage** | 10d | 2025-09-01 | 2025-09-12 |  | 0d |  | 88h | 1,050 |
| 3 | 1.1.1 | Analyse des contraintes réglementaires | 2d | 2025-09-01 | 2025-09-02 |  | 0d | CP | 16h | 200 |
| 4 | 1.1.2 | Réunion de cadrage avec direction | 1d | 2025-09-03 | 2025-09-03 | 3 | 0d | CP; Direction | 16h | 150 |
| 5 | 1.1.3 | Définition des objectifs SMART | 1d | 2025-09-04 | 2025-09-04 | 4 | 0d | CP | 8h | 100 |
| 6 | 1.1.4 | Identification des parties prenantes | 1d | 2025-09-05 | 2025-09-05 | 5 | 0d | CP | 8h | 100 |
| 7 | 1.1.5 | Élaboration de la charte projet | 2d | 2025-09-08 | 2025-09-09 | 6 | 0d | CP | 16h | 300 |
| 8 | 1.1.6 | Validation de la charte par la direction | 1d | 2025-09-10 | 2025-09-10 | 7 | 0d | Direction | 8h |  |
| 9 | 1.1.7 | Préparation planning initial | 1d | 2025-09-11 | 2025-09-11 | 8 | 0d | CP | 8h | 100 |
| 10 | 1.1.8 | Mise en place de la matrice RACI | 1d | 2025-09-12 | 2025-09-12 | 9 | 0d | CP | 8h | 100 |
| 11 | 1.2 | **Analyse des besoins** | 14d | 2025-09-15 | 2025-10-02 |  | 0d |  | 112h | 1,700 |
| 12 | 1.2.1 | Benchmark offres concurrentes | 2d | 2025-09-15 | 2025-09-16 | 10 | 0d | CP | 16h | 200 |
| 13 | 1.2.2 | Interviews RH & alumni | 3d | 2025-09-17 | 2025-09-19 | 12 | 0d | Formateurs | 24h | 600 |
| 14 | 1.2.3 | Collecte données CRM | 2d | 2025-09-22 | 2025-09-23 | 13 | 0d | CP | 16h | 200 |
| 15 | 1.2.4 | Analyse des tendances CPF/OPCO | 1d | 2025-09-24 | 2025-09-24 | 14 | 0d | RQ | 8h | 100 |
| 16 | 1.2.5 | Synthèse des besoins | 2d | 2025-09-25 | 2025-09-26 | 15 | 0d | CP | 16h | 200 |
| 17 | 1.2.6 | Rédaction rapport d’analyse | 2d | 2025-09-29 | 2025-09-30 | 16 | 0d | CP | 16h | 200 |
| 18 | 1.2.7 | Validation par l'équipe projet | 1d | 2025-10-01 | 2025-10-01 | 17 | 0d | Toute l'équipe | 8h | 100 |
| 19 | 1.2.8 | Mise à jour du périmètre projet | 1d | 2025-10-02 | 2025-10-02 | 18 | 0d | CP | 8h | 100 |
| 20 | 1.3 | **Conception** | 17d | 2025-10-03 | 2025-10-27 |  | 0d |  | 136h | 2,250 |
| 21 | 1.3.1 | Élaboration des objectifs pédagogiques | 2d | 2025-10-03 | 2025-10-06 | 19 | 0d | RP | 16h | 200 |
| 22 | 1.3.2 | Scénarisation des modules e-learning | 5d | 2025-10-07 | 2025-10-13 | 21 | 0d | Formateurs | 40h | 800 |
| 23 | 1.3.3 | Définition des modalités d’évaluation | 2d | 2025-10-14 | 2025-10-15 | 22 | 0d | RQ | 16h | 150 |
| 24 | 1.3.4 | Storyboard des capsules vidéo | 3d | 2025-10-16 | 2025-10-20 | 23 | 0d | Formateurs | 24h | 500 |
| 25 | 1.3.5 | Préparation des supports d’atelier | 2d | 2025-10-21 | 2025-10-22 | 24 | 0d | Formateurs | 16h | 300 |
| 26 | 1.3.6 | Définition de la structure LMS | 2d | 2025-10-23 | 2025-10-24 | 25 | 0d | RP | 16h | 200 |
| 27 | 1.3.7 | Validation des choix pédagogiques | 1d | 2025-10-27 | 2025-10-27 | 26 | 0d | CP | 8h | 100 |

| ID | WBS | Task | Duration | Start | Finish | Predecessors | Total slack | Resources | Work | Cost |
| --- | --- | --- | --- | --- | --- | --- | --- | --- | --- | --- |
| 28 | 1.4 | **Production** | 17d | 2025-10-28 | 2025-11-19 |  | 0d |  | 136h | 2,600 |
| 29 | 1.4.1 | Enregistrement des vidéos | 4d | 2025-10-28 | 2025-10-31 | 27 | 0d | Formateurs | 32h | 1,000 |
| 30 | 1.4.2 | Montage et intégration LMS | 5d | 2025-11-03 | 2025-11-07 | 29 | 0d | Support tech | 40h | 700 |
| 31 | 1.4.3 | Création des quiz et cas pratiques | 3d | 2025-11-10 | 2025-11-12 | 30 | 0d | Formateurs | 24h | 300 |
| 32 | 1.4.4 | Recettage technique du parcours | 2d | 2025-11-13 | 2025-11-14 | 31 | 0d | RQ | 16h | 200 |
| 33 | 1.4.5 | Tests utilisateurs internes | 2d | 2025-11-17 | 2025-11-18 | 32 | 0d | Équipe projet | 16h | 300 |
| 34 | 1.4.6 | Mise en ligne finale | 1d | 2025-11-19 | 2025-11-19 | 33 | 0d | Support tech | 8h | 100 |
| 35 | 1.5 | **Pilote** | 8d | 2025-11-20 | 2025-12-01 |  | 0d |  | 64h | 1,100 |
| 36 | 1.5.1 | Préparation session pilote | 1d | 2025-11-20 | 2025-11-20 | 34 | 0d | Formateurs | 8h | 100 |
| 37 | 1.5.2 | Animation session pilote | 3d | 2025-11-21 | 2025-11-25 | 36 | 0d | Formateurs | 24h | 600 |
| 38 | 1.5.3 | Recueil des feedbacks participants | 2d | 2025-11-26 | 2025-11-27 | 37 | 0d | RQ | 16h | 200 |
| 39 | 1.5.4 | Analyse et ajustements | 2d | 2025-11-28 | 2025-12-01 | 38 | 0d | CP | 16h | 200 |
| 40 | 1.6 | **Communication** | 11d | 2025-12-02 | 2025-12-16 |  | 0d |  | 88h | 1,250 |
| 41 | 1.6.1 | Création kit marketing | 3d | 2025-12-02 | 2025-12-04 | 39 | 0d | Chargé de com | 24h | 400 |
| 42 | 1.6.2 | Création landing page CPF | 2d | 2025-12-05 | 2025-12-08 | 41 | 0d | Support tech | 16h | 200 |
| 43 | 1.6.3 | Formation des commerciaux | 2d | 2025-12-09 | 2025-12-10 | 42 | 0d | Formateurs | 16h | 300 |
| 44 | 1.6.4 | Campagne emailing de lancement | 2d | 2025-12-11 | 2025-12-12 | 43 | 0d | Chargé de com | 16h | 200 |
| 45 | 1.6.5 | Webinaire découverte | 1d | 2025-12-15 | 2025-12-15 | 44 | 0d | Formateurs | 8h | 150 |
| 46 | 1.6.6 | Lancement officiel | 1d | 2025-12-16 | 2025-12-16 | 45 | 0d | Toute l'équipe | 8h |  |
